# CSTv2.3

How a schedule from Primavera P6 changed from version to version. A marks actual dates.

## Version 1 (data date 2023-01-01, saved 2024-09-24, file CSTv2.3.xer)

| ID | WBS | Task | Duration | Start | Finish | Predecessors | Total float | Constraint |
| --- | --- | --- | --- | --- | --- | --- | --- | --- |
|  | Mil | **Milestones** |  | 2023-01-01 | 2024-11-14 |  |  |  |
|  | Gene | **General** |  | 2023-01-01 | 2024-11-14 |  |  |  |
| ContractNo_NTP |  | Issue Contractor NTP | 0d | 2023-01-01 | 2023-01-01 |  | -1.67d |  |
| ContractNo_AR01 |  | Access Restraint: Relocate Util before Bridge Demo | 0d | 2023-08-02 | 2023-08-02 | ContractNo_1030 FF, ContractNo_U430 | -0.67d | start on 2023-08-02 |
| ContractNo_MS03 |  | MS#03 - Full Beneficial Use | 0d | 2024-08-31 | 2024-08-31 | ContractNo_C320 FF, ContractNo_C885 FF, ContractNo_MS04 FF, ContractNo_P780 FF, ContractNo_1000 FF, ContractNo_U480 FF | 0d | finish on or before 2024-08-31 |
| ContractNo_MS04 |  | MS#04 - Perform Final Traffic Move | 0d | 2024-08-31 | 2024-08-31 | ContractNo_C885 FF | 0d | finish on or after 2024-08-31 |
| ContractNo_MS02 |  | MS#02 - Substantial Completion | 0d | 2024-10-01 | 2024-10-01 | ContractNo_C340 FF, ContractNo_C360 SF | 0.67d | finish on or before 2024-11-15 |
| ContractNo_MS01 |  | MS#01 - Contractor Field Completion | 0d | 2024-11-14 | 2024-11-14 | ContractNo_C470, ContractNo_1020 FF, ContractNo_C330 FF | 0d | finish on or before 2024-12-31 |
|  | Dura | **Durations** |  | 2023-01-01 | 2024-11-14 |  |  |  |
| ContractNo_1000 |  | Construction Contract Duration (NTP to FBU) | 608d | 2023-01-01 | 2024-08-31 | ContractNo_NTP SS | 0d |  |
| ContractNo_1010 |  | Construction Contract Duration (NTP to SC) | 639.67d | 2023-01-01 | 2024-10-01 | ContractNo_NTP SS, ContractNo_MS02 FF | 0.67d |  |
| ContractNo_1020 |  | Construction Contract Duration (NTP to CFC) | 683.67d | 2023-01-01 | 2024-11-14 | ContractNo_NTP SS | 0d |  |
| ContractNo_1030 |  | Construction Contract Duration (NTP to AR01) | 213.67d | 2023-01-01 | 2023-08-02 | ContractNo_NTP SS | -0.67d |  |
|  | Wid | **Project Wide** |  |  |  |  |  |  |
|  | Pre | **Preconstruction** |  | 2023-01-01 | 2023-07-12 |  |  |  |
| ContractNo_PreCon |  | Pre-Construction Meeting | 1d | 2023-01-03 | 2023-01-03 | ContractNo_NTP SS+2.33d | 14d |  |
|  | Prm | **Permitting** |  | 2023-01-03 | 2023-01-31 |  |  |  |
| ContractNo_P300 |  | Permit Coordination, Apply, Obtain | 20d | 2023-01-03 | 2023-01-31 | ContractNo_NTP | 264d |  |
|  | Pro | **Submittals & Procurements** |  | 2023-01-01 | 2023-07-12 |  |  |  |
|  | 8.01 | **Subsection 8.01: Subcontractor Approvals** |  |  |  |  |  |  |
|  | SitePro | **Licensed Site Professional** |  |  |  |  |  |  |
|  | StrucClean | **Structure Cleaning Subcontractor** |  |  |  |  |  |  |
|  | Elec | **Electrical Subcontractor** |  |  |  |  |  |  |
|  | BrdDemo | **Bridge Demolition Subcontractor** |  |  |  |  |  |  |
|  | 100 | **Item 100: Schedule of Operations** |  | 2023-01-01 | 2023-02-09 |  |  |  |
| ContractNo_P740 |  | Prepare & Submit - Initial Baseline Schedule | 10d | 2023-01-01 | 2023-01-10 | ContractNo_NTP | 568d |  |
| ContractNo_P770 |  | Prepare & Submit - Scheduler Resume | 5d | 2023-01-03 | 2023-01-09 | ContractNo_NTP SS | 407d |  |
| ContractNo_P790 |  | Review & Approve - Scheduler Resume | 5d | 2023-01-10 | 2023-01-14 | ContractNo_P770 | 594d |  |
| ContractNo_P750 |  | Review & Respond - Initial Baseline Schedule | 10d | 2023-01-11 | 2023-01-20 | ContractNo_P740 | 568d |  |
| ContractNo_P760 |  | Prepare & Submit - Final Baseline Schedule | 10d | 2023-01-21 | 2023-01-30 | ContractNo_P750 | 551d |  |
| ContractNo_P780 |  | Review & Approve - Final Baseline Schedule | 10d | 2023-01-31 | 2023-02-09 | ContractNo_P760, ContractNo_P790 FF | 568d |  |
|  | 114.1 | **Item 114.1: Demolition of Superstructure** |  | 2023-01-03 | 2023-03-09 |  |  |  |
| ContractNo_P620 |  | Prepare & Submit - Demolition Plan | 25d | 2023-01-03 | 2023-02-07 | ContractNo_NTP | 257d |  |
| ContractNo_P630 |  | Review & Approve - Demolition Plan | 30d | 2023-02-08 | 2023-03-09 | ContractNo_P620 | 376d |  |
|  | 119.5 | **Item 119.5: Construction Noise Control** |  |  |  |  |  |  |
|  | 149.2 | **Item 149.2: Public Outreach** |  | 2023-01-01 | 2023-02-09 |  |  |  |
| ContractNo_P1060 |  | Prepare & Submit - Public Outreach Plan | 10d | 2023-01-01 | 2023-01-10 | ContractNo_NTP SS | 13d |  |
| ContractNo_P1070 |  | Review & Approve - Public Outreach Plan | 30d | 2023-01-11 | 2023-02-09 | ContractNo_P1060 | 13d |  |
|  | 180.01 | **Item 180.01: Environmental Health & Safety Program** |  | 2023-01-03 | 2023-02-23 |  |  |  |
| ContractNo_P130 |  | Prepare & Submit - Environmental Health & Safety Plan | 15d | 2023-01-03 | 2023-01-24 | ContractNo_NTP | 4d |  |
| ContractNo_P140 |  | Review & Approve - Environmental Health & Safety Plan | 30d | 2023-01-25 | 2023-02-23 | ContractNo_P130 | 6d |  |
|  | 220 | **Items 220.x: Drainage Structures** |  | 2023-01-03 | 2023-05-15 |  |  |  |
| ContractNo_P550 |  | Prepare & Submit - Shop Drawings Drainage Structures | 10d | 2023-01-03 | 2023-01-17 | ContractNo_NTP | 308d |  |
| ContractNo_P560 |  | Review & Approve - Shop Drawings Drainage Structures | 30d | 2023-01-18 | 2023-02-16 | ContractNo_P550 | 448d |  |
| ContractNo_P580 |  | Fabrication & Delivery - Drainage Structures | 60d | 2023-02-17 | 2023-05-15 | ContractNo_P560 | 307d |  |
|  | 701.47 | **Item 701.47: Winter Concrete Plan** |  | 2023-01-03 | 2023-02-23 |  |  |  |
| ContractNo_P720 |  | Prepare & Submit - Winter Concrete Plan | 15d | 2023-01-03 | 2023-01-24 | ContractNo_NTP | 272d |  |
| ContractNo_P730 |  | Review & Approve - Winter Concrete Plan | 30d | 2023-01-25 | 2023-02-23 | ContractNo_P720 | 398d |  |
|  | 701.61 | **Item 701.61: Contractor Quality Control Plan** |  | 2023-01-03 | 2023-02-23 |  |  |  |
| ContractNo_P1080 |  | Prepare & Submit - Contractor Quality Control Plan | 15d | 2023-01-03 | 2023-01-24 | ContractNo_NTP SS | 4d |  |
| ContractNo_P1090 |  | Review & Approve - Contractor Quality Control Plan | 30d | 2023-01-25 | 2023-02-23 | ContractNo_P1080 | 6d |  |
|  | 756 | **Item 756: Stormwater Water Protection Plan** |  | 2023-01-03 | 2023-02-23 |  |  |  |
| ContractNo_P160 |  | Prepare & Submit - SWPPP | 15d | 2023-01-03 | 2023-01-24 | ContractNo_NTP | 4d |  |
| ContractNo_P170 |  | Review & Approve - SWPPP | 30d | 2023-01-25 | 2023-02-23 | ContractNo_P160 | 6d |  |
|  | 850 | **Items 850.x: Traffic Control for Construction and Maint Operations** |  | 2023-01-03 | 2023-02-23 |  |  |  |
| ContractNo_P190 |  | Prepare & Submit - Traffic Control Plan | 15d | 2023-01-03 | 2023-01-24 | ContractNo_NTP | -1d |  |
| ContractNo_P200 |  | Review & Approve - Traffic Control Plan | 30d | 2023-01-25 | 2023-02-23 | ContractNo_P190 | -1d |  |
|  | 991.1 | **Item 991.1: Control of Water** |  | 2023-01-03 | 2023-03-09 |  |  |  |
| ContractNo_P640 |  | Prepare & Submit - Water Control Plan | 25d | 2023-01-03 | 2023-02-07 | ContractNo_NTP | 135d |  |
| ContractNo_P650 |  | Review & Approve - Water Control Plan | 30d | 2023-02-08 | 2023-03-09 | ContractNo_P640 | 196d |  |
|  | 995.01 | **Item 995.01: Bridge** |  | 2023-01-03 | 2023-07-12 |  |  |  |
|  | SEP | **Steel Erection Procedure** |  | 2023-01-03 | 2023-03-09 |  |  |  |
| ContractNo_P600 |  | Prepare & Submit - Steel Erection Procedure | 25d | 2023-01-03 | 2023-02-07 | ContractNo_NTP | 266d |  |
| ContractNo_P610 |  | Review & Approve - Steel Erection Procedure | 30d | 2023-02-08 | 2023-03-09 | ContractNo_P600 | 390d |  |
|  | 901 | **SubItem 901: 4000 PSI 1.5 in., 565 Cement Concrete** |  | 2023-01-03 | 2023-03-09 |  |  |  |
| ContractNo_P100 |  | Prepare & Submitt - Concrete Mix Design | 25d | 2023-01-03 | 2023-02-07 | ContractNo_NTP | 262d |  |
| ContractNo_P110 |  | Review & Approve - Concrete Mix Design | 30d | 2023-02-08 | 2023-03-09 | ContractNo_P100 | 384d |  |
|  | 960.01 | **SubItem 960.01: Structural Steel - Coated Steel** |  | 2023-01-03 | 2023-06-28 |  |  |  |
| ContractNo_P450 |  | Prepare & Submit - Shop Drawings Steel Beams | 10d | 2023-01-03 | 2023-01-17 | ContractNo_NTP SS | 191d |  |
| ContractNo_P460 |  | Review & Approve - Shop Drawings Steel Beams | 30d | 2023-01-18 | 2023-02-16 | ContractNo_P450 | 278d |  |

| ID | WBS | Task | Duration | Start | Finish | Predecessors | Total float |
| --- | --- | --- | --- | --- | --- | --- | --- |
| ContractNo_P480 |  | Fabrication & Delivery - Steel Beams | 90d | 2023-02-17 | 2023-06-28 | ContractNo_P460 | 191d |
|  | 975.1 | **SubItem 975.1: Metal Bridge Railing (3 Rail), Steel (Type S3-TL4)** |  | 2023-01-03 | 2023-06-28 |  |  |
| ContractNo_P690 |  | Prepare & Submit -Shop Drawings Bridge Rail | 10d | 2023-01-03 | 2023-01-17 | ContractNo_NTP SS | 230d |
| ContractNo_P700 |  | Review & Approve - Shop Drawings Bridge Rail | 30d | 2023-01-18 | 2023-02-16 | ContractNo_P690 | 334d |
| ContractNo_P710 |  | Fabrication & Delivery - Bridge Rail | 90d | 2023-02-17 | 2023-06-28 | ContractNo_P700 | 227d |
|  | PD | **Precast Decks** |  | 2023-01-03 | 2023-07-12 |  |  |
| ContractNo_P660 |  | Prepare & Submit - Shop Drawings Precast Deck | 20d | 2023-01-03 | 2023-01-31 | ContractNo_NTP | 188d |
| ContractNo_P670 |  | Review & Approve - Shop Drawings Precast Deck | 30d | 2023-02-01 | 2023-03-02 | ContractNo_P660 | 273d |
| ContractNo_P680 |  | Fabrication & Delivery - Precast Deck | 90d | 2023-03-03 | 2023-07-12 | ContractNo_P670 | 188d |
|  | TPD | **Temporary Pavement Design** |  | 2023-01-03 | 2023-02-23 |  |  |
| ContractNo_P220 |  | Prepare & Submit - Temporary Pavement Design | 15d | 2023-01-03 | 2023-01-24 | ContractNo_NTP | 311d |
| ContractNo_P230 |  | Review & Approve - Temporary Pavement Design | 30d | 2023-01-25 | 2023-02-23 | ContractNo_P220 | 454d |
|  | Uti | **Utility** |  | 2023-01-01 | 2023-08-02 |  |  |
|  | URP | **Utility Relocation & Coordination Plan** |  | 2023-01-01 | 2023-01-21 |  |  |
| ContractNo_P250 |  | Prepare & Submit - Early Utiltiy Relocation Request\Coordination Plan | 14d | 2023-01-01 | 2023-01-14 | ContractNo_NTP | 16d |
| ContractNo_P260 |  | Review & Approve - Early Utiltiy Relocation Request\Coordination Plan | 7d | 2023-01-15 | 2023-01-21 | ContractNo_P250 | 16d |
|  | Not | **Utility Notifications & Meetings** |  | 2023-01-22 | 2023-02-20 |  |  |
| ContractNo_U100 |  | Coordinate/Mobilization Period - Relocation w/ Utility Company - [insert Utility 1 Name] | 30d | 2023-01-22 | 2023-02-20 | ContractNo_P260 | 16d |
| ContractNo_U350 |  | Coordinate/Mobilization Period - Relocation w/ Utility Company - [insert Utility 2 Name] | 30d | 2023-01-22 | 2023-02-20 | ContractNo_P260 | 51d |
| ContractNo_U360 |  | Coordinate/Mobilization Period - Relocation w/ Utility Company - [insert Utility 3 Name] | 30d | 2023-01-22 | 2023-02-20 | ContractNo_P260 | 87d |
| ContractNo_U370 |  | Coordinate/Mobilization Period - Relocation w/ Utility Company - [insert Utility 4 Name] | 30d | 2023-01-22 | 2023-02-20 | ContractNo_P260 | 126d |
|  | Rel | **Utility Relocation** |  | 2023-03-10 | 2023-08-02 |  |  |
|  | 1 | **Utility 1 PUC Tasks** |  | 2023-03-10 | 2023-04-13 |  |  |
| ContractNo_U340 |  | Utility 1 Task 1: Copy Activity Name from PUC Form | 20d | 2023-03-10 | 2023-04-06 | ContractNo_P260, ContractNo_U100, ContractNo_C900 | -1d |
| ContractNo_U120 |  | Utility 1 Task 2: Copy Activity Name from PUC Form | 5d | 2023-04-07 | 2023-04-13 | ContractNo_U340 | -1d |
|  | 2 | **Utility 2 PUC Tasks** |  | 2023-04-14 | 2023-05-19 |  |  |
| ContractNo_U380 |  | Utility 2 Task 1: Copy Activity Name from PUC Form | 20d | 2023-04-14 | 2023-05-12 | ContractNo_U120, ContractNo_U350 | -1d |
| ContractNo_U390 |  | Utility 2 Task 2: Copy Activity Name from PUC Form | 5d | 2023-05-15 | 2023-05-19 | ContractNo_U380 | -1d |
|  | 3 | **Utility 3 PUC Tasks** |  | 2023-05-22 | 2023-06-27 |  |  |
| ContractNo_U400 |  | Utility 3 Task 1: Copy Activity Name from PUC Form | 20d | 2023-05-22 | 2023-06-20 | ContractNo_U390, ContractNo_U360 | -1d |
| ContractNo_U410 |  | Utility 3 Task 2: Copy Activity Name from PUC Form | 5d | 2023-06-21 | 2023-06-27 | ContractNo_U400 | -1d |
|  | 4 | **Utility 4 PUC Tasks** |  | 2023-06-28 | 2023-08-02 |  |  |
| ContractNo_U420 |  | Utility 4 Task 1: Copy Activity Name from PUC Form | 20d | 2023-06-28 | 2023-07-26 | ContractNo_U410, ContractNo_U370 | -1d |
| ContractNo_U430 |  | Utility 4 Task 2: Copy Activity Name from PUC Form | 5d | 2023-07-27 | 2023-08-02 | ContractNo_U420 | -1d |
|  | SCONN | **Utility Service Connections** |  | 2023-01-04 | 2023-03-13 |  |  |
| ContractNo_U440 |  | Contractor Request WO# for Service Connection @ Location XXX (If Required) | 5d | 2023-01-04 | 2023-01-10 | ContractNo_PreCon, ContractNo_NTP SS | 385d |
| ContractNo_U450 |  | Utility Assigns WO# for Service Connection @ Location XXX (If Required) | 5d | 2023-01-11 | 2023-01-18 | ContractNo_U440 | 385d |
| ContractNo_U460 |  | Utility Completes Design and Requests payment for Service Connection WO# (If Required) | 20d | 2023-01-18 | 2023-02-07 | ContractNo_U450 | 561.67d |
| ContractNo_U470 |  | Contractor installs UG conduit for Service Connection @ Location XXX (If Required) | 5d | 2023-03-03 | 2023-03-09 | ContractNo_U460, ContractNo_C900 SS | 369d |
| ContractNo_U480 |  | Utility performs Service Connection @ Location XXX (If Required) | 2d | 2023-03-10 | 2023-03-13 | ContractNo_U470 | 369d |
|  | Con | **Construction** |  | 2023-01-04 | 2024-08-30 |  |  |
|  | Gene | **General** |  |  |  |  |  |
|  | Mobi | **Start-up** |  | 2023-01-04 | 2023-03-09 |  |  |
| ContractNo_C070 |  | Contractor Mobilize | 20d | 2023-01-04 | 2023-02-01 | ContractNo_NTP, ContractNo_PreCon | 14d |
| ContractNo_C100 |  | Establish Engineer's Field Office | 20d | 2023-01-04 | 2023-02-01 | ContractNo_C070 SS, ContractNo_PreCon | 14d |
| ContractNo_C910 |  | MassDOT Baseline Survey / Layout of Utility Pole Locations | 20d | 2023-01-04 | 2023-02-01 | ContractNo_PreCon | 19d |
| ContractNo_C370 |  | Install Traffic Devices, Barriers, Signage | 5d | 2023-02-24 | 2023-03-02 | ContractNo_P1070, ContractNo_C100, ContractNo_P200 | -1d |
| ContractNo_C080 |  | Install SWPPP Systems | 5d | 2023-03-03 | 2023-03-09 | ContractNo_C070, ContractNo_P170, ContractNo_P140, ContractNo_P1090, ContractNo_C370 | 238d |
| ContractNo_C900 |  | Contractor Performs Utility Enabling Work (If Required) | 5d | 2023-03-03 | 2023-03-09 | ContractNo_P170, ContractNo_P140, ContractNo_P1090, ContractNo_C910, ContractNo_C370 | -1d |
|  | Ph1 | **Stage 1** |  | 2023-08-03 | 2023-11-08 |  |  |
|  | StpA | **Step A** |  | 2023-08-03 | 2023-09-13 |  |  |
| ContractNo_C465 |  | Install Temporary Shielding - P1SA NB | 7d | 2023-08-03 | 2023-08-11 | ContractNo_C080, ContractNo_P300, ContractNo_P1090, ContractNo_U430 | 138d |
| ContractNo_C480 |  | Environmental Protection of Box Turtles - P1SA NB | 5d | 2023-08-03 | 2023-08-09 | ContractNo_P1090, ContractNo_U430 | 30d |
| ContractNo_C485 |  | Install Water Control Measures - P1SA NB | 6d | 2023-08-10 | 2023-08-17 | ContractNo_C480, ContractNo_P650, ContractNo_P1090 | 30d |
| ContractNo_C475 |  | Demo Existing Superstructure - P1SA NB | 4d | 2023-08-14 | 2023-08-17 | ContractNo_C080, ContractNo_C465 | 138d |
| ContractNo_C490 |  | Excavate Abutments & Surrounding Area - P1SA NB | 8d | 2023-08-18 | 2023-08-29 | ContractNo_C475, ContractNo_C485, ContractNo_P1090 | 138d |
| ContractNo_C505 |  | Demo Existing Substructure - P1SA NB | 6d | 2023-08-30 | 2023-09-07 | ContractNo_C475, ContractNo_C485, ContractNo_C490, ContractNo_AR01, ContractNo_P630 | 138d |
| ContractNo_C515 |  | Set & Grout Precast Abutments - P1SA NB (NOTE: Ensure Grout Cure Period is accounted for) | 4d | 2023-09-08 | 2023-09-13 | ContractNo_C505, ContractNo_P110, ContractNo_P730, ContractNo_P1090 | 138d |
|  | StpB | **Step B** |  | 2023-09-13 | 2023-11-08 |  |  |
| ContractNo_C525 |  | Install Steel Beams - P1SB NB | 6d | 2023-09-13 | 2023-09-21 | ContractNo_C515, ContractNo_P480, ContractNo_P610 | 144.12d |
| ContractNo_C535 |  | Install Precast Decks - P1SB NB | 3d | 2023-09-22 | 2023-09-26 | ContractNo_C525, ContractNo_P680 | 138d |
| ContractNo_C920 |  | Postension Precast Decks - P1SB NB | 1d | 2023-09-27 | 2023-09-27 | ContractNo_C535 | 138d |
| ContractNo_C545 |  | Grout Precast Decks - P1SB NB (NOTE: Ensure Grout Cure Period is accounted for) | 3d | 2023-09-28 | 2023-10-02 | ContractNo_C535, ContractNo_C920 | 138d |
| ContractNo_C555 |  | F/R/Pour Sidewalk Placement 1 - P1SB NB | 4d | 2023-10-03 | 2023-10-06 | ContractNo_C545 | 138d |
| ContractNo_C930 |  | 72 Hour Placement Cure Period for Sidewalks - P1SB NB | 3d | 2023-10-06 | 2023-10-09 | ContractNo_C555 | 205.67d |
| ContractNo_C940 |  | Sidewalk Placement 2 - P1SB NB | 2d | 2023-10-10 | 2023-10-11 | ContractNo_C930 | 141d |
| ContractNo_C950 |  | Full Cure Period for Sidewalks - P1SB NB | 14d | 2023-10-11 | 2023-10-25 | ContractNo_C940 | 207.67d |
| ContractNo_C575 |  | Install waterproofing - P1SB NB | 3d | 2023-10-26 | 2023-10-30 | ContractNo_C555, ContractNo_C950 | 48d |
| ContractNo_C580 |  | Place Protective Course Pavement - P1SB NB | 1d | 2023-10-31 | 2023-10-31 | ContractNo_C575, ContractNo_P230, ContractNo_C950 | 48d |
| ContractNo_C565 |  | Install Railings - P1SB NB | 4d | 2023-11-01 | 2023-11-06 | ContractNo_C555, ContractNo_P710, ContractNo_C950, ContractNo_C580 | 141d |

| ID | WBS | Task | Duration | Start | Finish | Predecessors | Total float |
| --- | --- | --- | --- | --- | --- | --- | --- |
| ContractNo_C590 |  | Install Pavement Markers, Sign and Stripe - P1SB NB | 2d | 2023-11-01 | 2023-11-02 | ContractNo_C580 | 50d |
| ContractNo_C585 |  | Complete Phase 1 - P1SB NB | 0d | 2023-11-06 | 2023-11-06 | ContractNo_C590, ContractNo_C565 | 141d |
| ContractNo_C595 |  | Set Jersey Barriers & Signage - P1SB NB | 2d | 2023-11-07 | 2023-11-08 | ContractNo_C590, ContractNo_C585 | 141d |
|  | StpC | **Step C** |  |  |  |  |  |
|  | StpD | **Step D** |  |  |  |  |  |
|  | Ph2 | **Stage 2** |  | 2023-11-09 | 2024-08-30 |  |  |
|  | StpA | **Step A** |  | 2023-11-09 | 2024-06-24 |  |  |
| ContractNo_C750 |  | Traffic Switch from Phase I | 2d | 2023-11-09 | 2023-11-10 | ContractNo_C595, ContractNo_C585 | 141d |
| ContractNo_C765 |  | Install Temporary Shielding - P2SA SB | 5d | 2023-11-13 | 2023-11-17 | ContractNo_C750 | 141d |
| ContractNo_C755 |  | Install Water Control Measures - P2SA SB | 6d | 2024-06-03 | 2024-06-10 | ContractNo_C585 | 2d |
| ContractNo_C790 |  | Excavate Abutments & Surrounding Area - P2SA SB | 8d | 2024-06-11 | 2024-06-21 | ContractNo_C755 | 10d |
| ContractNo_C805 |  | Demo Existing Substructure - P2SA SB | 5d | 2024-06-11 | 2024-06-17 | ContractNo_C755, ContractNo_C765 | 2d |
| ContractNo_C815 |  | Set & Grout Precast Abutments - P2SA SB (NOTE: Ensure Grout Cure Period is accounted for) | 4d | 2024-06-18 | 2024-06-24 | ContractNo_C805 | 2d |
|  | StpB | **Step B** |  | 2024-06-25 | 2024-08-28 |  |  |
| ContractNo_C825 |  | Install Steel Beams - P2SB SB | 6d | 2024-06-25 | 2024-07-02 | ContractNo_C815 | 2d |
| ContractNo_C835 |  | Install Precast Decks - P2SB SB | 4d | 2024-07-03 | 2024-07-09 | ContractNo_C825 | 2d |
| ContractNo_C960 |  | Postension Precast Decks - P2SB SB | 1d | 2024-07-10 | 2024-07-10 | ContractNo_C835 | 2d |
| ContractNo_C845 |  | Grout Precast Decks - P2SB SB | 3d | 2024-07-11 | 2024-07-15 | ContractNo_C835, ContractNo_C960 | 2d |
| ContractNo_C855 |  | F/R/Pour Sidewalk Placement 1 - P2SB SB | 2d | 2024-07-16 | 2024-07-17 | ContractNo_C845 | 2d |
| ContractNo_C970 |  | 72 Hour Placement Cure Period for Sidewalks - P2SB SB | 3d | 2024-07-17 | 2024-07-20 | ContractNo_C855 | 3.67d |
| ContractNo_C980 |  | Sidewalk Placement 2 - P2SB SB | 2d | 2024-07-22 | 2024-07-23 | ContractNo_C970 | 2d |
| ContractNo_C990 |  | Full Cure Period for Sidewalks - P2SB SB | 14d | 2024-07-23 | 2024-08-06 | ContractNo_C980 | 2.67d |
| ContractNo_C875 |  | Install waterproofing - P2SB SB | 3d | 2024-08-07 | 2024-08-09 | ContractNo_C855, ContractNo_C990 | 2d |
| ContractNo_C1000 |  | Place Protective Course Pavement - P2SB SB | 3d | 2024-08-12 | 2024-08-14 | ContractNo_C875 | 2d |
| ContractNo_C865 |  | Install Railings - P2SB SB | 4d | 2024-08-15 | 2024-08-20 | ContractNo_C855, ContractNo_C1000 | 2d |
| ContractNo_C880 |  | Place Base & Top Pavement - P2SB SB | 4d | 2024-08-21 | 2024-08-26 | ContractNo_C875, ContractNo_C320, ContractNo_C865 | 2d |
| ContractNo_C890 |  | Install Pavement Markers, Sign and Stripe - P2SB SB | 2d | 2024-08-27 | 2024-08-28 | ContractNo_C880 | 2d |
| ContractNo_C885 |  | Complete Phase 2 - P2SB SB | 0d | 2024-08-28 | 2024-08-28 | ContractNo_C890, ContractNo_C865 | 2d |
|  | StpC | **Step C** |  | 2024-06-24 | 2024-08-30 |  |  |
| ContractNo_C190 |  | Approach Work - Raise Grades - P2SC SB RDWY | 16d | 2024-06-24 | 2024-07-16 | ContractNo_C790 | 10d |
| ContractNo_C200 |  | Repair Underground Drainage Structure - P2SC SB RDWY | 5d | 2024-07-17 | 2024-07-23 | ContractNo_C190, ContractNo_P580 FF, ContractNo_U430 | 10d |
| ContractNo_C320 |  | Backfill & Grade - P2SC SB RDWY | 12d | 2024-07-24 | 2024-08-08 | ContractNo_C200 | 10d |
| ContractNo_C470 |  | Install Landscape, Sod, Etc. - P2SC SB RDWY | 11d | 2024-08-16 | 2024-08-30 | ContractNo_C320 | 30d |
|  | StpD | **Step D** |  |  |  |  |  |
|  | Ph3 | **Stage 3** |  |  |  |  |  |
|  | StpA | **Step A** |  |  |  |  |  |
|  | StpB | **Step B** |  |  |  |  |  |
|  | StpC | **Step C** |  |  |  |  |  |
|  | StpD | **Step D** |  |  |  |  |  |
|  | Ph4 | **Stage 4** |  |  |  |  |  |
|  | StpA | **Step A** |  |  |  |  |  |
|  | StpB | **Step B** |  |  |  |  |  |
|  | StpC | **Step C** |  |  |  |  |  |
|  | StpD | **Step D** |  |  |  |  |  |
|  | Ph5 | **Stage 5** |  |  |  |  |  |
|  | StpA | **Step A** |  |  |  |  |  |
|  | StpB | **Step B** |  |  |  |  |  |
|  | StpC | **Step C** |  |  |  |  |  |
|  | StpD | **Step D** |  |  |  |  |  |
|  | Clo | **Close-Out** |  | 2024-09-03 | 2024-11-14 |  |  |
| ContractNo_C340 |  | MassDOT Inspection & Generate Punchlist | 21d | 2024-09-03 | 2024-10-01 | ContractNo_MS03 | 0d |
| ContractNo_C360 |  | Prepare & Submit Remaining Project Documentation | 20d | 2024-09-03 | 2024-09-30 | ContractNo_MS03 | 21d |
| ContractNo_C330 |  | Complete Punchlist & Demobilize | 30d | 2024-10-02 | 2024-11-14 | ContractNo_MS04, ContractNo_C340, ContractNo_MS02 | 0d |
|  | Pla | **Placeholder** |  | 2023-01-01 | 2023-11-28 |  |  |
| ContractNo_CAL03A |  | Cal03A-7d/8hr/No Holidays | 100d | 2023-01-01 | 2023-04-10 |  | 584d |
| ContractNo_CAL04 |  | Cal04-7D/8Hr, No Hol (milestones) | 33.33d | 2023-01-01 | 2023-04-10 |  | 194.67d |
| ContractNo_CAL03 |  | Cal03-7D/8Hr, 12 Hol | 100d | 2023-01-02 | 2023-04-13 |  | 562d |
| ContractNo_CAL08 |  | Cal08-7D/8Hr, 12 Hol - Mjr Rdwy | 100d | 2023-01-02 | 2023-04-20 |  | 515d |
| ContractNo_C&RP |  | Cost & Resource Placeholder (Delete After Importing) | 100d | 2023-01-03 | 2023-05-25 |  | 368d |
| ContractNo_CAL01 |  | Cal01-5D/8Hr, 12 Hol | 100d | 2023-01-03 | 2023-05-25 |  | 368d |
| ContractNo_CAL02 |  | Cal02-6D/8Hr, 12 Hol | 100d | 2023-01-03 | 2023-05-02 |  | 464d |
| ContractNo_CAL06 |  | Cal06-5D/8Hr, 12 Hol - Mjr Rdwy | 100d | 2023-01-03 | 2023-05-30 |  | 355d |
| ContractNo_CAL07 |  | Cal07-6D/8Hr, 12 Hol - Mjr Rdwy | 100d | 2023-01-03 | 2023-05-05 |  | 434d |
| ContractNo_CAL10 |  | Cal10-Winter Ineff, 5D/12 Hol | 100d | 2023-01-03 | 2023-06-16 |  | 333d |
| ContractNo_CAL11A |  | Cal11A-Winter Shut 5D/8Hr, 12Hol - Mjr Rdwy | 100d | 2023-01-03 | 2023-05-30 |  | 283d |
| ContractNo_CAL12A |  | Cal12A-Paving, 5D/12 Hol - Mjr Rdwy | 100d | 2023-01-03 | 2023-05-30 |  | 265d |
| ContractNo_CAL16 |  | Cal16-Water Access 2, 5D/12Hol (Fish Migration) | 50d | 2023-01-03 | 2023-03-15 |  | 209d |
| ContractNo_CAL05 |  | Cal05-MBTA Night No Hol | 100d | 2023-01-03 | 2023-05-25 |  | 368d |
| ContractNo_CAL11 |  | Cal11-Winter Shut 5D/8Hr, 12Hol | 100d | 2023-03-16 | 2023-08-08 |  | 246d |
| ContractNo_CAL14 |  | Cal14-Planting, 5D/12Hol - Deciduous | 100d | 2023-03-21 | 2023-11-28 |  | 94d |

| ID | WBS | Task | Duration | Start | Finish | Total float |
| --- | --- | --- | --- | --- | --- | --- |
| ContractNo_CAL12 |  | Cal12-Paving, 5D/12 Hol | 100d | 2023-04-03 | 2023-08-24 | 213d |
| ContractNo_CAL13 |  | Cal13-Planting, 5D/12Hol - Evergreen | 50d | 2023-04-18 | 2023-09-12 | 96d |
| ContractNo_CAL17 |  | Cal17 - Reclaimation - 5d/12hol | 100d | 2023-04-18 | 2023-09-08 | 149d |
| ContractNo_CAL15 |  | Cal15-Water Access1, 5D/12Hol (Low Flow) | 50d | 2023-06-01 | 2023-08-11 | 117d |
|  | Deleted | **Deleted Activities** |  |  |  |  |

## Version 2 (data date 2026-01-01, saved 2026-01-16, file CSTv2.4.xer)

Last finish 2024-11-14 → 2027-10-20 (+1070d).

Changed:

| ID | Task | Start | Finish | Duration | Total float | Other |
| --- | --- | --- | --- | --- | --- | --- |
| Mil | **Milestones** | 2023-01-01 → 2026-01-01 (+1096d) | 2024-11-14 → 2027-10-20 (+1070d) |  |  |  |
| Gene | **General** | 2023-01-01 → 2026-01-01 (+1096d) | 2024-11-14 → 2027-10-20 (+1070d) |  |  |  |
| ContractNo_NTP | Issue Contractor NTP | 2023-01-01 → 2026-01-01 (+1096d) | 2023-01-01 → 2026-01-01 (+1096d) |  | -1.67d → 1.33d |  |
| ContractNo_AR01 | Access Restraint: Relocate Util before Bridge Demo | 2023-08-02 → 2026-08-02 (+1096d) | 2023-08-02 → 2026-08-02 (+1096d) |  | -0.67d → 0d | constraint start on 2023-08-02 → start on 2026-08-02 |
| ContractNo_MS03 | MS#03 - Full Beneficial Use | 2024-08-31 → 2027-08-31 (+1095d) | 2024-08-31 → 2027-08-31 (+1095d) |  |  | constraint finish on or before 2024-08-31 → finish on or before 2027-08-31 |
| ContractNo_MS04 | MS#04 - Perform Final Traffic Move | 2024-08-31 → 2027-08-31 (+1095d) | 2024-08-31 → 2027-08-31 (+1095d) |  |  | constraint finish on or after 2024-08-31 → finish on or after 2027-08-31 |
| ContractNo_MS02 | MS#02 - Substantial Completion | 2024-10-01 → 2027-09-20 (+1084d) | 2024-10-01 → 2027-09-20 (+1084d) |  |  | constraint finish on or before 2024-11-15 → finish on or before 2027-11-15 |
| ContractNo_MS01 | MS#01 - Contractor Field Completion | 2024-11-14 → 2027-10-20 (+1070d) | 2024-11-14 → 2027-10-20 (+1070d) |  |  | constraint finish on or before 2024-12-31 → finish on or before 2027-12-31 |
| Dura | **Durations** | 2023-01-01 → 2026-01-01 (+1096d) | 2024-11-14 → 2027-10-20 (+1070d) |  |  |  |
| ContractNo_1000 | Construction Contract Duration (NTP to FBU) | 2023-01-01 → 2026-01-01 (+1096d) | 2024-08-31 → 2027-08-31 (+1095d) | 608d → 607d |  |  |
| ContractNo_1010 | Construction Contract Duration (NTP to SC) | 2023-01-01 → 2026-01-01 (+1096d) | 2024-10-01 → 2027-09-20 (+1084d) | 639.67d → 627.67d |  |  |
| ContractNo_1020 | Construction Contract Duration (NTP to CFC) | 2023-01-01 → 2026-01-01 (+1096d) | 2024-11-14 → 2027-10-20 (+1070d) | 683.67d → 657.67d |  |  |
| ContractNo_1030 | Construction Contract Duration (NTP to AR01) | 2023-01-01 → 2026-01-01 (+1096d) | 2023-08-02 → 2026-08-02 (+1096d) | 213.67d → 213d | -0.67d → 0d |  |
| Pre | **Preconstruction** | 2023-01-01 → 2026-01-01 (+1096d) | 2023-07-12 → 2026-07-09 (+1093d) |  |  |  |
| ContractNo_PreCon | Pre-Construction Meeting | 2023-01-03 → 2026-01-05 (+1098d) | 2023-01-03 → 2026-01-05 (+1098d) |  | 14d → 13d |  |
| Prm | **Permitting** | 2023-01-03 → 2026-01-02 (+1095d) | 2023-01-31 → 2026-01-30 (+1095d) |  |  |  |
| ContractNo_P300 | Permit Coordination, Apply, Obtain | 2023-01-03 → 2026-01-02 (+1095d) | 2023-01-31 → 2026-01-30 (+1095d) |  | 264d → 261d |  |
| Pro | **Submittals & Procurements** | 2023-01-01 → 2026-01-01 (+1096d) | 2023-07-12 → 2026-07-09 (+1093d) |  |  |  |
| 100 | **Item 100: Schedule of Operations** | 2023-01-01 → 2026-01-01 (+1096d) | 2023-02-09 → 2026-02-09 (+1096d) |  |  |  |
| ContractNo_P740 | Prepare & Submit - Initial Baseline Schedule | 2023-01-01 → 2026-01-01 (+1096d) | 2023-01-10 → 2026-01-10 (+1096d) |  | 568d → 567d |  |
| ContractNo_P770 | Prepare & Submit - Scheduler Resume | 2023-01-03 → 2026-01-02 (+1095d) | 2023-01-09 → 2026-01-08 (+1095d) |  |  |  |
| ContractNo_P790 | Review & Approve - Scheduler Resume | 2023-01-10 → 2026-01-09 (+1095d) | 2023-01-14 → 2026-01-13 (+1095d) |  |  |  |
| ContractNo_P750 | Review & Respond - Initial Baseline Schedule | 2023-01-11 → 2026-01-11 (+1096d) | 2023-01-20 → 2026-01-20 (+1096d) |  | 568d → 567d |  |
| ContractNo_P760 | Prepare & Submit - Final Baseline Schedule | 2023-01-21 → 2026-01-21 (+1096d) | 2023-01-30 → 2026-01-30 (+1096d) |  | 551d → 549d |  |
| ContractNo_P780 | Review & Approve - Final Baseline Schedule | 2023-01-31 → 2026-01-31 (+1096d) | 2023-02-09 → 2026-02-09 (+1096d) |  | 568d → 567d |  |
| 114.1 | **Item 114.1: Demolition of Superstructure** | 2023-01-03 → 2026-01-02 (+1095d) | 2023-03-09 → 2026-03-08 (+1095d) |  |  |  |
| ContractNo_P620 | Prepare & Submit - Demolition Plan | 2023-01-03 → 2026-01-02 (+1095d) | 2023-02-07 → 2026-02-06 (+1095d) |  | 257d → 253d |  |
| ContractNo_P630 | Review & Approve - Demolition Plan | 2023-02-08 → 2026-02-07 (+1095d) | 2023-03-09 → 2026-03-08 (+1095d) |  | 376d → 374d |  |
| 149.2 | **Item 149.2: Public Outreach** | 2023-01-01 → 2026-01-01 (+1096d) | 2023-02-09 → 2026-02-09 (+1096d) |  |  |  |
| ContractNo_P1060 | Prepare & Submit - Public Outreach Plan | 2023-01-01 → 2026-01-01 (+1096d) | 2023-01-10 → 2026-01-10 (+1096d) |  | 13d → 14d |  |
| ContractNo_P1070 | Review & Approve - Public Outreach Plan | 2023-01-11 → 2026-01-11 (+1096d) | 2023-02-09 → 2026-02-09 (+1096d) |  | 13d → 14d |  |
| 180.01 | **Item 180.01: Environmental Health & Safety Program** | 2023-01-03 → 2026-01-02 (+1095d) | 2023-02-23 → 2026-02-22 (+1095d) |  |  |  |
| ContractNo_P130 | Prepare & Submit - Environmental Health & Safety Plan | 2023-01-03 → 2026-01-02 (+1095d) | 2023-01-24 → 2026-01-23 (+1095d) |  | 4d → 5d |  |
| ContractNo_P140 | Review & Approve - Environmental Health & Safety Plan | 2023-01-25 → 2026-01-24 (+1095d) | 2023-02-23 → 2026-02-22 (+1095d) |  | 6d → 8d |  |
| 220 | **Items 220.x: Drainage Structures** | 2023-01-03 → 2026-01-02 (+1095d) | 2023-05-15 → 2026-05-12 (+1093d) |  |  |  |
| ContractNo_P550 | Prepare & Submit - Shop Drawings Drainage Structures | 2023-01-03 → 2026-01-02 (+1095d) | 2023-01-17 → 2026-01-15 (+1094d) |  | 308d → 307d |  |
| ContractNo_P560 | Review & Approve - Shop Drawings Drainage Structures | 2023-01-18 → 2026-01-16 (+1094d) | 2023-02-16 → 2026-02-14 (+1094d) |  | 448d → 450d |  |
| ContractNo_P580 | Fabrication & Delivery - Drainage Structures | 2023-02-17 → 2026-02-17 (+1096d) | 2023-05-15 → 2026-05-12 (+1093d) |  |  |  |
| 701.47 | **Item 701.47: Winter Concrete Plan** | 2023-01-03 → 2026-01-02 (+1095d) | 2023-02-23 → 2026-02-22 (+1095d) |  |  |  |
| ContractNo_P720 | Prepare & Submit - Winter Concrete Plan | 2023-01-03 → 2026-01-02 (+1095d) | 2023-01-24 → 2026-01-23 (+1095d) |  | 272d → 269d |  |
| ContractNo_P730 | Review & Approve - Winter Concrete Plan | 2023-01-25 → 2026-01-24 (+1095d) | 2023-02-23 → 2026-02-22 (+1095d) |  | 398d → 396d |  |
| 701.61 | **Item 701.61: Contractor Quality Control Plan** | 2023-01-03 → 2026-01-02 (+1095d) | 2023-02-23 → 2026-02-22 (+1095d) |  |  |  |
| ContractNo_P1080 | Prepare & Submit - Contractor Quality Control Plan | 2023-01-03 → 2026-01-02 (+1095d) | 2023-01-24 → 2026-01-23 (+1095d) |  | 4d → 5d |  |
| ContractNo_P1090 | Review & Approve - Contractor Quality Control Plan | 2023-01-25 → 2026-01-24 (+1095d) | 2023-02-23 → 2026-02-22 (+1095d) |  | 6d → 8d |  |
| 756 | **Item 756: Stormwater Water Protection Plan** | 2023-01-03 → 2026-01-02 (+1095d) | 2023-02-23 → 2026-02-22 (+1095d) |  |  |  |
| ContractNo_P160 | Prepare & Submit - SWPPP | 2023-01-03 → 2026-01-02 (+1095d) | 2023-01-24 → 2026-01-23 (+1095d) |  | 4d → 5d |  |
| ContractNo_P170 | Review & Approve - SWPPP | 2023-01-25 → 2026-01-24 (+1095d) | 2023-02-23 → 2026-02-22 (+1095d) |  | 6d → 8d |  |
| 850 | **Items 850.x: Traffic Control for Construction and Maint Operations** | 2023-01-03 → 2026-01-02 (+1095d) | 2023-02-23 → 2026-02-22 (+1095d) |  |  |  |
| ContractNo_P190 | Prepare & Submit - Traffic Control Plan | 2023-01-03 → 2026-01-02 (+1095d) | 2023-01-24 → 2026-01-23 (+1095d) |  | -1d → 0d |  |
| ContractNo_P200 | Review & Approve - Traffic Control Plan | 2023-01-25 → 2026-01-24 (+1095d) | 2023-02-23 → 2026-02-22 (+1095d) |  | -1d → 1d |  |
| 991.1 | **Item 991.1: Control of Water** | 2023-01-03 → 2026-01-02 (+1095d) | 2023-03-09 → 2026-03-08 (+1095d) |  |  |  |
| ContractNo_P640 | Prepare & Submit - Water Control Plan | 2023-01-03 → 2026-01-02 (+1095d) | 2023-02-07 → 2026-02-06 (+1095d) |  |  |  |
| ContractNo_P650 | Review & Approve - Water Control Plan | 2023-02-08 → 2026-02-07 (+1095d) | 2023-03-09 → 2026-03-08 (+1095d) |  | 196d → 198d |  |
| 995.01 | **Item 995.01: Bridge** | 2023-01-03 → 2026-01-02 (+1095d) | 2023-07-12 → 2026-07-09 (+1093d) |  |  |  |
| SEP | **Steel Erection Procedure** | 2023-01-03 → 2026-01-02 (+1095d) | 2023-03-09 → 2026-03-08 (+1095d) |  |  |  |
| ContractNo_P600 | Prepare & Submit - Steel Erection Procedure | 2023-01-03 → 2026-01-02 (+1095d) | 2023-02-07 → 2026-02-06 (+1095d) |  | 266d → 263d |  |
| ContractNo_P610 | Review & Approve - Steel Erection Procedure | 2023-02-08 → 2026-02-07 (+1095d) | 2023-03-09 → 2026-03-08 (+1095d) |  | 390d → 388d |  |
| 901 | **SubItem 901: 4000 PSI 1.5 in., 565 Cement Concrete** | 2023-01-03 → 2026-01-02 (+1095d) | 2023-03-09 → 2026-03-08 (+1095d) |  |  |  |
| ContractNo_P100 | Prepare & Submitt - Concrete Mix Design | 2023-01-03 → 2026-01-02 (+1095d) | 2023-02-07 → 2026-02-06 (+1095d) |  | 262d → 259d |  |
| ContractNo_P110 | Review & Approve - Concrete Mix Design | 2023-02-08 → 2026-02-07 (+1095d) | 2023-03-09 → 2026-03-08 (+1095d) |  | 384d → 382d |  |
| 960.01 | **SubItem 960.01: Structural Steel - Coated Steel** | 2023-01-03 → 2026-01-02 (+1095d) | 2023-06-28 → 2026-06-25 (+1093d) |  |  |  |
| ContractNo_P450 | Prepare & Submit - Shop Drawings Steel Beams | 2023-01-03 → 2026-01-02 (+1095d) | 2023-01-17 → 2026-01-15 (+1094d) |  | 191d → 189d |  |
| ContractNo_P460 | Review & Approve - Shop Drawings Steel Beams | 2023-01-18 → 2026-01-16 (+1094d) | 2023-02-16 → 2026-02-14 (+1094d) |  | 278d → 277d |  |
| ContractNo_P480 | Fabrication & Delivery - Steel Beams | 2023-02-17 → 2026-02-17 (+1096d) | 2023-06-28 → 2026-06-25 (+1093d) |  | 191d → 190d |  |
| 975.1 | **SubItem 975.1: Metal Bridge Railing (3 Rail), Steel (Type S3-TL4)** | 2023-01-03 → 2026-01-02 (+1095d) | 2023-06-28 → 2026-06-25 (+1093d) |  |  |  |
| ContractNo_P690 | Prepare & Submit -Shop Drawings Bridge Rail | 2023-01-03 → 2026-01-02 (+1095d) | 2023-01-17 → 2026-01-15 (+1094d) |  | 230d → 226d |  |
| ContractNo_P700 | Review & Approve - Shop Drawings Bridge Rail | 2023-01-18 → 2026-01-16 (+1094d) | 2023-02-16 → 2026-02-14 (+1094d) |  | 334d → 332d |  |
| ContractNo_P710 | Fabrication & Delivery - Bridge Rail | 2023-02-17 → 2026-02-17 (+1096d) | 2023-06-28 → 2026-06-25 (+1093d) |  | 227d → 226d |  |
| PD | **Precast Decks** | 2023-01-03 → 2026-01-02 (+1095d) | 2023-07-12 → 2026-07-09 (+1093d) |  |  |  |
| ContractNo_P660 | Prepare & Submit - Shop Drawings Precast Deck | 2023-01-03 → 2026-01-02 (+1095d) | 2023-01-31 → 2026-01-30 (+1095d) |  |  |  |

| ID | Task | Start | Finish | Total float |
| --- | --- | --- | --- | --- |
| ContractNo_P670 | Review & Approve - Shop Drawings Precast Deck | 2023-02-01 → 2026-01-31 (+1095d) | 2023-03-02 → 2026-03-01 (+1095d) |  |
| ContractNo_P680 | Fabrication & Delivery - Precast Deck | 2023-03-03 → 2026-03-02 (+1095d) | 2023-07-12 → 2026-07-09 (+1093d) | 188d → 187d |
| TPD | **Temporary Pavement Design** | 2023-01-03 → 2026-01-02 (+1095d) | 2023-02-23 → 2026-02-22 (+1095d) |  |
| ContractNo_P220 | Prepare & Submit - Temporary Pavement Design | 2023-01-03 → 2026-01-02 (+1095d) | 2023-01-24 → 2026-01-23 (+1095d) | 311d → 308d |
| ContractNo_P230 | Review & Approve - Temporary Pavement Design | 2023-01-25 → 2026-01-24 (+1095d) | 2023-02-23 → 2026-02-22 (+1095d) | 454d → 452d |
| Uti | **Utility** | 2023-01-01 → 2026-01-01 (+1096d) | 2023-08-02 → 2026-07-30 (+1093d) |  |
| URP | **Utility Relocation & Coordination Plan** | 2023-01-01 → 2026-01-01 (+1096d) | 2023-01-21 → 2026-01-21 (+1096d) |  |
| ContractNo_P250 | Prepare & Submit - Early Utiltiy Relocation Request\Coordination Plan | 2023-01-01 → 2026-01-01 (+1096d) | 2023-01-14 → 2026-01-14 (+1096d) | 16d → 17d |
| ContractNo_P260 | Review & Approve - Early Utiltiy Relocation Request\Coordination Plan | 2023-01-15 → 2026-01-15 (+1096d) | 2023-01-21 → 2026-01-21 (+1096d) | 16d → 17d |
| Not | **Utility Notifications & Meetings** | 2023-01-22 → 2026-01-22 (+1096d) | 2023-02-20 → 2026-02-20 (+1096d) |  |
| ContractNo_U100 | Coordinate/Mobilization Period - Relocation w/ Utility Company - [insert Utility 1 Name] | 2023-01-22 → 2026-01-22 (+1096d) | 2023-02-20 → 2026-02-20 (+1096d) | 16d → 17d |
| ContractNo_U350 | Coordinate/Mobilization Period - Relocation w/ Utility Company - [insert Utility 2 Name] | 2023-01-22 → 2026-01-22 (+1096d) | 2023-02-20 → 2026-02-20 (+1096d) | 51d → 52d |
| ContractNo_U360 | Coordinate/Mobilization Period - Relocation w/ Utility Company - [insert Utility 3 Name] | 2023-01-22 → 2026-01-22 (+1096d) | 2023-02-20 → 2026-02-20 (+1096d) | 87d → 88d |
| ContractNo_U370 | Coordinate/Mobilization Period - Relocation w/ Utility Company - [insert Utility 4 Name] | 2023-01-22 → 2026-01-22 (+1096d) | 2023-02-20 → 2026-02-20 (+1096d) | 126d → 125d |
| Rel | **Utility Relocation** | 2023-03-10 → 2026-03-09 (+1095d) | 2023-08-02 → 2026-07-30 (+1093d) |  |
| 1 | **Utility 1 PUC Tasks** | 2023-03-10 → 2026-03-09 (+1095d) | 2023-04-13 → 2026-04-10 (+1093d) |  |
| ContractNo_U340 | Utility 1 Task 1: Copy Activity Name from PUC Form | 2023-03-10 → 2026-03-09 (+1095d) | 2023-04-06 → 2026-04-03 (+1093d) | -1d → 1d |
| ContractNo_U120 | Utility 1 Task 2: Copy Activity Name from PUC Form | 2023-04-07 → 2026-04-06 (+1095d) | 2023-04-13 → 2026-04-10 (+1093d) | -1d → 1d |
| 2 | **Utility 2 PUC Tasks** | 2023-04-14 → 2026-04-13 (+1095d) | 2023-05-19 → 2026-05-18 (+1095d) |  |
| ContractNo_U380 | Utility 2 Task 1: Copy Activity Name from PUC Form | 2023-04-14 → 2026-04-13 (+1095d) | 2023-05-12 → 2026-05-11 (+1095d) | -1d → 1d |
| ContractNo_U390 | Utility 2 Task 2: Copy Activity Name from PUC Form | 2023-05-15 → 2026-05-12 (+1093d) | 2023-05-19 → 2026-05-18 (+1095d) | -1d → 1d |
| 3 | **Utility 3 PUC Tasks** | 2023-05-22 → 2026-05-19 (+1093d) | 2023-06-27 → 2026-06-24 (+1093d) |  |
| ContractNo_U400 | Utility 3 Task 1: Copy Activity Name from PUC Form | 2023-05-22 → 2026-05-19 (+1093d) | 2023-06-20 → 2026-06-16 (+1092d) | -1d → 1d |
| ContractNo_U410 | Utility 3 Task 2: Copy Activity Name from PUC Form | 2023-06-21 → 2026-06-17 (+1092d) | 2023-06-27 → 2026-06-24 (+1093d) | -1d → 1d |
| 4 | **Utility 4 PUC Tasks** | 2023-06-28 → 2026-06-25 (+1093d) | 2023-08-02 → 2026-07-30 (+1093d) |  |
| ContractNo_U420 | Utility 4 Task 1: Copy Activity Name from PUC Form | 2023-06-28 → 2026-06-25 (+1093d) | 2023-07-26 → 2026-07-23 (+1093d) | -1d → 1d |
| ContractNo_U430 | Utility 4 Task 2: Copy Activity Name from PUC Form | 2023-07-27 → 2026-07-24 (+1093d) | 2023-08-02 → 2026-07-30 (+1093d) | -1d → 1d |
| SCONN | **Utility Service Connections** | 2023-01-04 → 2026-01-06 (+1098d) | 2023-03-13 → 2026-03-10 (+1093d) |  |
| ContractNo_U440 | Contractor Request WO# for Service Connection @ Location XXX (If Required) | 2023-01-04 → 2026-01-06 (+1098d) | 2023-01-10 → 2026-01-12 (+1098d) | 385d → 382d |
| ContractNo_U450 | Utility Assigns WO# for Service Connection @ Location XXX (If Required) | 2023-01-11 → 2026-01-13 (+1098d) | 2023-01-18 → 2026-01-20 (+1098d) | 385d → 382d |
| ContractNo_U460 | Utility Completes Design and Requests payment for Service Connection WO# (If Required) | 2023-01-18 → 2026-01-20 (+1098d) | 2023-02-07 → 2026-02-09 (+1098d) | 561.67d → 556.67d |
| ContractNo_U470 | Contractor installs UG conduit for Service Connection @ Location XXX (If Required) | 2023-03-03 → 2026-03-02 (+1095d) | 2023-03-09 → 2026-03-06 (+1093d) |  |
| ContractNo_U480 | Utility performs Service Connection @ Location XXX (If Required) | 2023-03-10 → 2026-03-09 (+1095d) | 2023-03-13 → 2026-03-10 (+1093d) |  |
| Con | **Construction** | 2023-01-04 → 2026-01-06 (+1098d) | 2024-08-30 → 2027-08-30 (+1095d) |  |
| Mobi | **Start-up** | 2023-01-04 → 2026-01-06 (+1098d) | 2023-03-09 → 2026-03-06 (+1093d) |  |
| ContractNo_C070 | Contractor Mobilize | 2023-01-04 → 2026-01-06 (+1098d) | 2023-02-01 → 2026-02-03 (+1098d) | 14d → 13d |
| ContractNo_C100 | Establish Engineer's Field Office | 2023-01-04 → 2026-01-06 (+1098d) | 2023-02-01 → 2026-02-03 (+1098d) | 14d → 13d |
| ContractNo_C910 | MassDOT Baseline Survey / Layout of Utility Pole Locations | 2023-01-04 → 2026-01-06 (+1098d) | 2023-02-01 → 2026-02-03 (+1098d) | 19d → 18d |
| ContractNo_C370 | Install Traffic Devices, Barriers, Signage | 2023-02-24 → 2026-02-23 (+1095d) | 2023-03-02 → 2026-02-27 (+1093d) | -1d → 1d |
| ContractNo_C080 | Install SWPPP Systems | 2023-03-03 → 2026-03-02 (+1095d) | 2023-03-09 → 2026-03-06 (+1093d) | 238d → 237d |
| ContractNo_C900 | Contractor Performs Utility Enabling Work (If Required) | 2023-03-03 → 2026-03-02 (+1095d) | 2023-03-09 → 2026-03-06 (+1093d) | -1d → 1d |
| Ph1 | **Stage 1** | 2023-08-03 → 2026-07-31 (+1093d) | 2023-11-08 → 2026-11-10 (+1098d) |  |
| StpA | **Step A** | 2023-08-03 → 2026-07-31 (+1093d) | 2023-09-13 → 2026-09-10 (+1093d) |  |
| ContractNo_C465 | Install Temporary Shielding - P1SA NB | 2023-08-03 → 2026-07-31 (+1093d) | 2023-08-11 → 2026-08-10 (+1095d) | 138d → 137d |
| ContractNo_C480 | Environmental Protection of Box Turtles - P1SA NB | 2023-08-03 → 2026-07-31 (+1093d) | 2023-08-09 → 2026-08-06 (+1093d) | 30d → 32d |
| ContractNo_C485 | Install Water Control Measures - P1SA NB | 2023-08-10 → 2026-08-07 (+1093d) | 2023-08-17 → 2026-08-14 (+1093d) | 30d → 32d |
| ContractNo_C475 | Demo Existing Superstructure - P1SA NB | 2023-08-14 → 2026-08-11 (+1093d) | 2023-08-17 → 2026-08-14 (+1093d) | 138d → 137d |
| ContractNo_C490 | Excavate Abutments & Surrounding Area - P1SA NB | 2023-08-18 → 2026-08-17 (+1095d) | 2023-08-29 → 2026-08-26 (+1093d) | 138d → 137d |
| ContractNo_C505 | Demo Existing Substructure - P1SA NB | 2023-08-30 → 2026-08-27 (+1093d) | 2023-09-07 → 2026-09-03 (+1092d) | 138d → 137d |
| ContractNo_C515 | Set & Grout Precast Abutments - P1SA NB (NOTE: Ensure Grout Cure Period is accounted for) | 2023-09-08 → 2026-09-04 (+1092d) | 2023-09-13 → 2026-09-10 (+1093d) | 138d → 137d |
| StpB | **Step B** | 2023-09-13 → 2026-09-10 (+1093d) | 2023-11-08 → 2026-11-10 (+1098d) |  |
| ContractNo_C525 | Install Steel Beams - P1SB NB | 2023-09-13 → 2026-09-10 (+1093d) | 2023-09-21 → 2026-09-18 (+1093d) |  |
| ContractNo_C535 | Install Precast Decks - P1SB NB | 2023-09-22 → 2026-09-21 (+1095d) | 2023-09-26 → 2026-09-23 (+1093d) | 138d → 137d |
| ContractNo_C920 | Postension Precast Decks - P1SB NB | 2023-09-27 → 2026-09-24 (+1093d) | 2023-09-27 → 2026-09-24 (+1093d) | 138d → 137d |
| ContractNo_C545 | Grout Precast Decks - P1SB NB (NOTE: Ensure Grout Cure Period is accounted for) | 2023-09-28 → 2026-09-25 (+1093d) | 2023-10-02 → 2026-09-29 (+1093d) | 138d → 137d |
| ContractNo_C555 | F/R/Pour Sidewalk Placement 1 - P1SB NB | 2023-10-03 → 2026-09-30 (+1093d) | 2023-10-06 → 2026-10-05 (+1095d) | 138d → 137d |
| ContractNo_C930 | 72 Hour Placement Cure Period for Sidewalks - P1SB NB | 2023-10-06 → 2026-10-05 (+1095d) | 2023-10-09 → 2026-10-08 (+1095d) | 205.67d → 203.67d |
| ContractNo_C940 | Sidewalk Placement 2 - P1SB NB | 2023-10-10 → 2026-10-09 (+1095d) | 2023-10-11 → 2026-10-13 (+1098d) | 141d → 137d |
| ContractNo_C950 | Full Cure Period for Sidewalks - P1SB NB | 2023-10-11 → 2026-10-13 (+1098d) | 2023-10-25 → 2026-10-27 (+1098d) | 207.67d → 202.67d |
| ContractNo_C575 | Install waterproofing - P1SB NB | 2023-10-26 → 2026-10-28 (+1098d) | 2023-10-30 → 2026-10-30 (+1096d) | 48d → 44d |
| ContractNo_C580 | Place Protective Course Pavement - P1SB NB | 2023-10-31 → 2026-11-02 (+1098d) | 2023-10-31 → 2026-11-02 (+1098d) | 48d → 44d |
| ContractNo_C565 | Install Railings - P1SB NB | 2023-11-01 → 2026-11-03 (+1098d) | 2023-11-06 → 2026-11-06 (+1096d) | 141d → 137d |
| ContractNo_C590 | Install Pavement Markers, Sign and Stripe - P1SB NB | 2023-11-01 → 2026-11-03 (+1098d) | 2023-11-02 → 2026-11-04 (+1098d) | 50d → 46d |
| ContractNo_C585 | Complete Phase 1 - P1SB NB | 2023-11-06 → 2026-11-06 (+1096d) | 2023-11-06 → 2026-11-06 (+1096d) | 141d → 137d |
| ContractNo_C595 | Set Jersey Barriers & Signage - P1SB NB | 2023-11-07 → 2026-11-09 (+1098d) | 2023-11-08 → 2026-11-10 (+1098d) | 141d → 137d |
| Ph2 | **Stage 2** | 2023-11-09 → 2026-11-12 (+1099d) | 2024-08-30 → 2027-08-30 (+1095d) |  |
| StpA | **Step A** | 2023-11-09 → 2026-11-12 (+1099d) | 2024-06-24 → 2027-06-21 (+1092d) |  |
| ContractNo_C750 | Traffic Switch from Phase I | 2023-11-09 → 2026-11-12 (+1099d) | 2023-11-10 → 2026-11-13 (+1099d) | 141d → 137d |
| ContractNo_C765 | Install Temporary Shielding - P2SA SB | 2023-11-13 → 2026-11-16 (+1099d) | 2023-11-17 → 2026-11-20 (+1099d) | 141d → 137d |
| ContractNo_C755 | Install Water Control Measures - P2SA SB | 2024-06-03 → 2027-06-01 (+1093d) | 2024-06-10 → 2027-06-08 (+1093d) |  |

| ID | Task | Start | Finish | Total float |
| --- | --- | --- | --- | --- |
| ContractNo_C790 | Excavate Abutments & Surrounding Area - P2SA SB | 2024-06-11 → 2027-06-09 (+1093d) | 2024-06-21 → 2027-06-18 (+1092d) | 10d → 11d |
| ContractNo_C805 | Demo Existing Substructure - P2SA SB | 2024-06-11 → 2027-06-09 (+1093d) | 2024-06-17 → 2027-06-15 (+1093d) |  |
| ContractNo_C815 | Set & Grout Precast Abutments - P2SA SB (NOTE: Ensure Grout Cure Period is accounted for) | 2024-06-18 → 2027-06-16 (+1093d) | 2024-06-24 → 2027-06-21 (+1092d) |  |
| StpB | **Step B** | 2024-06-25 → 2027-06-22 (+1092d) | 2024-08-28 → 2027-08-25 (+1092d) |  |
| ContractNo_C825 | Install Steel Beams - P2SB SB | 2024-06-25 → 2027-06-22 (+1092d) | 2024-07-02 → 2027-06-29 (+1092d) |  |
| ContractNo_C835 | Install Precast Decks - P2SB SB | 2024-07-03 → 2027-06-30 (+1092d) | 2024-07-09 → 2027-07-06 (+1092d) |  |
| ContractNo_C960 | Postension Precast Decks - P2SB SB | 2024-07-10 → 2027-07-07 (+1092d) | 2024-07-10 → 2027-07-07 (+1092d) |  |
| ContractNo_C845 | Grout Precast Decks - P2SB SB | 2024-07-11 → 2027-07-08 (+1092d) | 2024-07-15 → 2027-07-12 (+1092d) |  |
| ContractNo_C855 | F/R/Pour Sidewalk Placement 1 - P2SB SB | 2024-07-16 → 2027-07-13 (+1092d) | 2024-07-17 → 2027-07-14 (+1092d) |  |
| ContractNo_C970 | 72 Hour Placement Cure Period for Sidewalks - P2SB SB | 2024-07-17 → 2027-07-14 (+1092d) | 2024-07-20 → 2027-07-17 (+1092d) | 3.67d → 4.67d |
| ContractNo_C980 | Sidewalk Placement 2 - P2SB SB | 2024-07-22 → 2027-07-19 (+1092d) | 2024-07-23 → 2027-07-20 (+1092d) | 2d → 3d |
| ContractNo_C990 | Full Cure Period for Sidewalks - P2SB SB | 2024-07-23 → 2027-07-20 (+1092d) | 2024-08-06 → 2027-08-03 (+1092d) | 2.67d → 5.67d |
| ContractNo_C875 | Install waterproofing - P2SB SB | 2024-08-07 → 2027-08-04 (+1092d) | 2024-08-09 → 2027-08-06 (+1092d) | 2d → 3d |
| ContractNo_C1000 | Place Protective Course Pavement - P2SB SB | 2024-08-12 → 2027-08-09 (+1092d) | 2024-08-14 → 2027-08-11 (+1092d) | 2d → 3d |
| ContractNo_C865 | Install Railings - P2SB SB | 2024-08-15 → 2027-08-12 (+1092d) | 2024-08-20 → 2027-08-17 (+1092d) | 2d → 3d |
| ContractNo_C880 | Place Base & Top Pavement - P2SB SB | 2024-08-21 → 2027-08-18 (+1092d) | 2024-08-26 → 2027-08-23 (+1092d) | 2d → 3d |
| ContractNo_C890 | Install Pavement Markers, Sign and Stripe - P2SB SB | 2024-08-27 → 2027-08-24 (+1092d) | 2024-08-28 → 2027-08-25 (+1092d) | 2d → 3d |
| ContractNo_C885 | Complete Phase 2 - P2SB SB | 2024-08-28 → 2027-08-25 (+1092d) | 2024-08-28 → 2027-08-25 (+1092d) | 2d → 3d |
| StpC | **Step C** | 2024-06-24 → 2027-06-21 (+1092d) | 2024-08-30 → 2027-08-30 (+1095d) |  |
| ContractNo_C190 | Approach Work - Raise Grades - P2SC SB RDWY | 2024-06-24 → 2027-06-21 (+1092d) | 2024-07-16 → 2027-07-13 (+1092d) | 10d → 11d |
| ContractNo_C200 | Repair Underground Drainage Structure - P2SC SB RDWY | 2024-07-17 → 2027-07-14 (+1092d) | 2024-07-23 → 2027-07-20 (+1092d) | 10d → 11d |
| ContractNo_C320 | Backfill & Grade - P2SC SB RDWY | 2024-07-24 → 2027-07-21 (+1092d) | 2024-08-08 → 2027-08-05 (+1092d) | 10d → 11d |
| ContractNo_C470 | Install Landscape, Sod, Etc. - P2SC SB RDWY | 2024-08-16 → 2027-08-16 (+1095d) | 2024-08-30 → 2027-08-30 (+1095d) | 30d → 32d |
| Clo | **Close-Out** | 2024-09-03 → 2027-08-31 (+1092d) | 2024-11-14 → 2027-10-20 (+1070d) |  |
| ContractNo_C340 | MassDOT Inspection & Generate Punchlist | 2024-09-03 → 2027-08-31 (+1092d) | 2024-10-01 → 2027-09-20 (+1084d) |  |
| ContractNo_C360 | Prepare & Submit Remaining Project Documentation | 2024-09-03 → 2027-08-31 (+1092d) | 2024-09-30 → 2027-09-28 (+1093d) | 21d → 14d |
| ContractNo_C330 | Complete Punchlist & Demobilize | 2024-10-02 → 2027-09-21 (+1084d) | 2024-11-14 → 2027-10-20 (+1070d) |  |
| Pla | **Placeholder** | 2023-01-01 → 2026-01-01 (+1096d) | 2023-11-28 → 2026-12-01 (+1099d) |  |
| ContractNo_CAL04 | Cal04-7D/8Hr, No Hol (milestones) | 2023-01-01 → 2026-01-01 (+1096d) | 2023-04-10 → 2026-02-03 (+1030d) | 194.67d → 624.33d |
| ContractNo_CAL03A | Cal03A-7d/8hr/No Holidays | 2023-01-01 → 2026-01-01 (+1096d) | 2023-04-10 → 2026-04-10 (+1096d) | 584d → 558d |
| ContractNo_C&RP | Cost & Resource Placeholder (Delete After Importing) | 2023-01-03 → 2026-01-02 (+1095d) | 2023-05-25 → 2026-05-27 (+1098d) | 368d → 350d |
| ContractNo_CAL01 | Cal01-5D/8Hr, 12 Hol | 2023-01-03 → 2026-01-02 (+1095d) | 2023-05-25 → 2026-05-27 (+1098d) | 368d → 350d |
| ContractNo_CAL02 | Cal02-6D/8Hr, 12 Hol | 2023-01-03 → 2026-01-02 (+1095d) | 2023-05-02 → 2026-05-01 (+1095d) | 464d → 442d |
| ContractNo_CAL03 | Cal03-7D/8Hr, 12 Hol | 2023-01-02 → 2026-01-02 (+1096d) | 2023-04-13 → 2026-04-13 (+1096d) | 562d → 536d |
| ContractNo_CAL06 | Cal06-5D/8Hr, 12 Hol - Mjr Rdwy | 2023-01-03 → 2026-01-02 (+1095d) | 2023-05-30 → 2026-05-29 (+1095d) | 355d → 334d |
| ContractNo_CAL07 | Cal07-6D/8Hr, 12 Hol - Mjr Rdwy | 2023-01-03 → 2026-01-02 (+1095d) | 2023-05-05 → 2026-05-05 (+1096d) | 434d → 412d |
| ContractNo_CAL08 | Cal08-7D/8Hr, 12 Hol - Mjr Rdwy | 2023-01-02 → 2026-01-02 (+1096d) | 2023-04-20 → 2026-04-17 (+1093d) | 515d → 490d |
| ContractNo_CAL10 | Cal10-Winter Ineff, 5D/12 Hol | 2023-01-03 → 2026-01-02 (+1095d) | 2023-06-16 → 2026-06-18 (+1098d) | 333d → 313d |
| ContractNo_CAL16 | Cal16-Water Access 2, 5D/12Hol (Fish Migration) | 2023-01-03 → 2026-01-02 (+1095d) | 2023-03-15 → 2026-03-16 (+1097d) | 209d → 197d |
| ContractNo_CAL05 | Cal05-MBTA Night No Hol | 2023-01-03 → 2026-01-02 (+1095d) | 2023-05-25 → 2026-05-27 (+1098d) | 368d → 350d |
| ContractNo_CAL11 | Cal11-Winter Shut 5D/8Hr, 12Hol | 2023-03-16 → 2026-03-16 (+1096d) | 2023-08-08 → 2026-08-06 (+1094d) | 246d → 230d |
| ContractNo_CAL11A | Cal11A-Winter Shut 5D/8Hr, 12Hol - Mjr Rdwy | 2023-01-03 → 2026-03-16 (+1168d) | 2023-05-30 → 2026-08-11 (+1169d) | 283d → 216d |
| ContractNo_CAL14 | Cal14-Planting, 5D/12Hol - Deciduous | 2023-03-21 → 2026-03-23 (+1098d) | 2023-11-28 → 2026-12-01 (+1099d) | 94d → 73d |
| ContractNo_CAL12 | Cal12-Paving, 5D/12 Hol | 2023-04-03 → 2026-04-01 (+1094d) | 2023-08-24 → 2026-08-24 (+1096d) | 213d → 196d |
| ContractNo_CAL12A | Cal12A-Paving, 5D/12 Hol - Mjr Rdwy | 2023-01-03 → 2026-04-01 (+1184d) | 2023-05-30 → 2026-08-27 (+1185d) | 265d → 185d |
| ContractNo_CAL17 | Cal17 - Reclaimation - 5d/12hol | 2023-04-18 → 2026-04-15 (+1093d) | 2023-09-08 → 2026-09-08 (+1096d) | 149d → 153d |
| ContractNo_CAL13 | Cal13-Planting, 5D/12Hol - Evergreen | 2023-04-18 → 2026-04-16 (+1094d) | 2023-09-12 → 2026-09-14 (+1098d) | 96d → 95d |
| ContractNo_CAL15 | Cal15-Water Access1, 5D/12Hol (Low Flow) | 2023-06-01 → 2026-06-01 (+1096d) | 2023-08-11 → 2026-08-11 (+1096d) | 117d → 121d |
